# Current kiLO Project Schedule

How a schedule from MS Project changed from version to version. A marks actual dates.

## Version 1 (saved 2006-02-19, file project-schedule_BASELINED.mpp)

| ID | Task | Duration | Start | Finish | Predecessors | Complete | Total float | Constraint |
| --- | --- | --- | --- | --- | --- | --- | --- | --- |
| 1 | Detail Requirements | 2d? | 2006-01-09 | 2006-01-10 |  |  | 12.5d |  |
| 2 | Review Requirements | 2d? | 2006-01-16 | 2006-01-17 | 1 |  | 9.5d | start no earlier than 2006-01-16 |
| 3 | Detail Requirements further | 2d? | 2006-01-24 | 2006-01-25 |  |  | 51d | start no earlier than 2006-01-24 |
| 4 | Review Requirements Detail | 2d? | 2006-01-26 | 2006-01-27 | 3 |  | 51d | start no earlier than 2006-01-26 |
| 5 | Determine process for change management | 2h? | 2006-01-24 | 2006-01-24 |  |  | 68.25d | start no earlier than 2006-01-24 |
| 6 | Determine metrics | 5h? | 2006-01-20 | 2006-01-23 |  |  | 64.7d | start no earlier than 2006-01-20 |
| 7 | Priortize Requirements | 2h? | 2006-01-18 | 2006-01-18 | 2 |  | 9.5d | start no earlier than 2006-01-17 |
| 8 | Update Risks Based on Requirements | 2h? | 2006-01-24 | 2006-01-24 | 7 |  | 68.25d | start no earlier than 2006-01-24 |
| 9 | Create/gather Testing templates | 4h? | 2006-01-24 | 2006-01-24 |  |  | 32d | start no earlier than 2006-01-24 |
| 10 | Create Acceptance Test Plan | 6h? | 2006-01-30 | 2006-01-31 | 4 |  | 51d | start no earlier than 2006-01-30 |
| 11 | Review Acceptance Test Plan | 3h? | 2006-01-31 | 2006-02-01 | 10 |  | 51d |  |
| 12 | High-level System Design | 4h? | 2006-01-18 | 2006-01-19 | 7 |  | 9.5d | start no earlier than 2006-01-18 |
| 13 | Review High-level System Design | 1h? | 2006-01-26 | 2006-01-26 | 12 |  | 5d | start no earlier than 2006-01-26 |
| 14 | Create detailed user use cases | 4h? | 2006-01-31 | 2006-01-31 |  |  | 62.25d | start no earlier than 2006-01-31 |
| 15 | Review detailed user use cases | 2h | 2006-02-02 | 2006-02-02 | 14 |  | 61.25d | start no earlier than 2006-02-02 |
| 16 | Create System Test Plan | 6h? | 2006-02-06 | 2006-02-07 | 9, 11 |  | 48.25d | start no earlier than 2006-02-06 |
| 17 | Review System Test Plan | 3h? | 2006-02-07 | 2006-02-08 | 16 |  | 48.25d |  |
| 18 | Create Detailed Architecture/Application Design | 17h? | 2006-01-26 | 2006-02-01 | 13 |  | 5d |  |
| 19 | Review Detailed Architecture/Application Design | 4h? | 2006-02-01 | 2006-02-02 | 18 |  | 5d |  |
| 20 | Create Integration Test Plan | 7h? | 2006-02-16 | 2006-02-17 | 9, 24 |  | 14d |  |
| 21 | Review Integration Test Plan | 2h? | 2006-02-17 | 2006-02-20 | 20 |  | 14d |  |
| 22 | Detailed Component Design | 40h? | 2006-02-02 | 2006-02-14 | 19 |  | 5d |  |
| 23 | MapPoint.NET Proof of concept on the server | 0h | 2006-02-17 | 2006-02-17 |  |  | 48.75d | start no earlier than 2006-02-17 |
| 24 | Reivew Detailed Component Design | 6h? | 2006-02-14 | 2006-02-15 | 22 |  | 5d |  |
| 25 | Create Unit Test Plan | 12h? | 2006-02-20 | 2006-02-23 | 24, 9, 21 |  | 14d |  |
| 26 | Review Unit Test Plan | 3h? | 2006-02-23 | 2006-02-23 | 25 |  | 14d |  |
| 27 | Create and review all Test Plans | 0h | 2006-02-23 | 2006-02-23 | 11, 17, 21, 26 |  | 43.75d |  |
| 28 | UI Paper Prototype | 16h? | 2006-01-31 | 2006-02-03 |  |  | 59.75d | start no earlier than 2006-01-31 |
| 29 | Sign off on UI Prototype | 0h | 2006-02-07 | 2006-02-07 | 28 |  | 58.75d | start no earlier than 2006-02-07 |
| 30 | Proof of concept with MapPoint.NET | 5h? | 2006-01-09 | 2006-01-10 |  |  | 27.5d |  |
| 31 | Research/Set-up Nokia IDE | 25h? | 2006-01-10 | 2006-01-18 | 30 |  | 27.5d |  |
| 32 | Nokia IDE Connects to the Internet | 0h | 2006-01-18 A | 2006-01-18 A | 31 | 100% |  |  |
| 33 | Proven interaction between the IDE and GPS Hardware | 4h? | 2006-02-01 A | 2006-02-01 | 32 | 20% | 17d | start no earlier than 2006-02-01 |
| 34 | Construct Components | 60h? | 2006-02-16 | 2006-03-08 | 24, 30, 31, 33 |  | 5d |  |
| 35 | Unit test each component | 25h? | 2006-03-09 | 2006-03-17 | 34, 26 |  | 5d |  |
| 36 | Bug Fixing (after Unit testing) | 20h? | 2006-03-17 | 2006-03-24 | 35 |  | 5d |  |
| 37 | Construct Components and conduct Unit tests | 0h | 2006-03-24 | 2006-03-24 | 36 |  | 5d |  |
| 38 | Integrate each component into system | 10h? | 2006-03-24 | 2006-03-28 | 37 |  | 5d |  |
| 39 | Integration Testing | 15h? | 2006-03-28 | 2006-04-03 | 38, 21, 36 |  | 5d |  |
| 40 | Bug Fixing (after integration testing) | 12h? | 2006-04-03 | 2006-04-06 | 39 |  | 5d |  |
| 41 | System test | 10h? | 2006-04-06 | 2006-04-10 | 17, 40 |  | 5d |  |
| 42 | Bug Fixing (after System testing) | 10h? | 2006-04-11 | 2006-04-13 | 41 |  | 5d |  |
| 43 | Acceptance test | 7h? | 2006-04-13 | 2006-04-17 | 11, 42 |  | 5d |  |
| 44 | Bug Fixing (after Acceptance testing) | 10h? | 2006-04-17 | 2006-04-19 | 43 |  | 5d |  |
| 45 | Sign off on application | 0h | 2006-04-19 | 2006-04-19 | 44 |  | 5d |  |
| 46 | Put together first quarter presentation | 10h? | 2006-02-17 | 2006-02-21 |  |  | 0d | finish no earlier than 2006-02-21 |
| 47 | Put together second quarter presentation | 20h | 2006-04-19 | 2006-04-26 | 46, 44 |  | 19d | start no earlier than 2006-04-10 |
| 48 | Investigate SOAP and MapPoint.NET interaction | 10h? | 2006-01-24 | 2006-01-26 |  |  | 66d | start no earlier than 2006-01-24 |
| 49 | Create Users Manual | 15h? | 2006-03-13 | 2006-03-16 |  |  | 29d | start no earlier than 2006-03-13 |
| 50 | Determine process for compiliation | 2h? | 2006-01-26 | 2006-01-26 |  |  | 66.25d | start no earlier than 2006-01-26 |
| 51 | Compile metrics | 20h? | 2006-04-05 A | 2006-04-11 | 6 | 4% | 10.75d | start no earlier than 2006-04-05 |
| 52 | Create Technical Report | 15h? | 2006-04-03 | 2006-04-06 |  |  | 14d | start no earlier than 2006-04-02 |

## Version 2 (saved 2006-05-01, file project-schedule.mpp)

Last finish 2006-04-26 → 2006-05-26 (+30d). Complete tasks 1 → 51.

Added:

| ID | Task | Duration | Start | Finish | Predecessors | Constraint | Resources |
| --- | --- | --- | --- | --- | --- | --- | --- |
| 35 | Model Component | 3h? | 2006-03-24 A | 2006-03-28 A | 34 | start no earlier than 2006-03-24 | Amanda |
| 36 | Test Model Component | 2h? | 2006-03-28 A | 2006-03-28 A | 35 |  | Amanda |
| 37 | Client UI Component | 20h? | 2006-03-28 A | 2006-05-02 | 36 |  | Lora |
| 38 | Unit test Client UI Component | 6h? | 2006-04-18 A | 2006-05-03 | 37 |  | Lora |
| 39 | Request Component | 6h? | 2006-04-04 A | 2006-04-05 A | 36, 44 | start no earlier than 2006-04-04 | Shawn |
| 40 | Unit Test Request Component | 5h? | 2006-04-05 A | 2006-04-06 A | 39 |  | Shawn |
| 41 | Mediator | 12h? | 2006-04-11 A | 2006-04-13 A |  | start no earlier than 2006-04-11 | Shawn |
| 42 | Unit test Mediator | 7h? | 2006-04-14 A | 2006-04-17 A | 41 |  | Shawn |
| 43 | XML Component | 5h? | 2006-03-28 A | 2006-03-29 A | 36 |  | Shawn |
| 44 | Unit Test XML Component | 2h? | 2006-03-29 A | 2006-03-30 A | 43 |  | Shawn |
| 45 | Servlet Component | 5h? | 2006-04-03 A | 2006-04-04 A | 48 |  | Nick |
| 46 | Unit Test Servlet Component | 3h? | 2006-04-04 A | 2006-04-05 A | 45 |  | Nick |
| 47 | Servlet State Component | 15h? | 2006-03-27 A | 2006-03-30 A | 34 | start no earlier than 2006-03-27 | Tom; Nick |
| 48 | Unit Test Servlet State Component | 7h? | 2006-03-30 A | 2006-04-03 A | 47 |  | Tom; Nick |
| 49 | MapPoint Component | 12h? | 2006-03-27 A | 2006-05-01 | 34 | start no earlier than 2006-03-27 | Tom |
| 50 | Unit Test mapPoint Component | 5h? | 2006-04-11 A | 2006-05-02 | 49 |  | Tom |
| 51 | Response Component | 7h? | 2006-03-28 A | 2006-03-30 A | 36 |  | Nick |

Changed:

| ID | Task | Start | Finish | Duration | Complete | Total float | Predecessors | Other |
| --- | --- | --- | --- | --- | --- | --- | --- | --- |
| 1 | Detail Requirements | 2006-01-09 A | 2006-01-10 A |  | 0% → 100% | 12.5d → none |  |  |
| 2 | Review Requirements | 2006-01-16 A | 2006-01-17 A |  | 0% → 100% | 9.5d → none |  |  |
| 3 | Detail Requirements further | 2006-01-24 A | 2006-01-25 → 2006-02-07 A (+13d) | 2d? → 2.1d? | 0% → 100% | 51d → none |  |  |
| 4 | Review Requirements Detail | 2006-01-26 A | 2006-01-27 → 2006-02-07 A (+11d) |  | 0% → 100% | 51d → none |  |  |
| 5 | Determine process for change management | 2006-01-24 A | 2006-01-24 A |  | 0% → 100% | 68.25d → none |  |  |
| 6 | Determine metrics | 2006-01-20 A | 2006-01-23 A |  | 0% → 100% | 64.7d → none |  |  |
| 7 | Priortize Requirements | 2006-01-18 A | 2006-01-18 A |  | 0% → 100% | 9.5d → none |  |  |
| 8 | Update Risks Based on Requirements | 2006-01-24 A | 2006-01-24 A |  | 0% → 100% | 68.25d → none |  |  |
| 9 | Create/gather Testing templates | 2006-01-24 A | 2006-01-24 A |  | 0% → 100% | 32d → none |  |  |
| 10 | Create Acceptance Test Plan | 2006-01-30 A | 2006-01-31 A |  | 0% → 100% | 51d → none |  |  |
| 11 | Review Acceptance Test Plan | 2006-01-31 A | 2006-02-01 A |  | 0% → 100% | 51d → none |  |  |
| 12 | High-level System Design | 2006-01-18 A | 2006-01-19 A |  | 0% → 100% | 9.5d → none |  |  |
| 13 | Review High-level System Design | 2006-01-26 A | 2006-01-26 A |  | 0% → 100% | 5d → none |  |  |
| 14 | Create detailed user use cases | 2006-01-31 A | 2006-01-31 A |  | 0% → 100% | 62.25d → none |  |  |
| 15 | Review detailed user use cases | 2006-02-02 A | 2006-02-02 A |  | 0% → 100% | 61.25d → none |  |  |
| 16 | Create System Test Plan | 2006-02-06 A | 2006-02-07 → 2006-03-10 A (+31d) | 6h? → 9h? | 0% → 100% | 48.25d → none | 9, 11 → 9 |  |
| 17 | Review System Test Plan | 2006-02-07 → 2006-03-13 A (+34d) | 2006-02-08 → 2006-03-20 A (+40d) |  | 0% → 100% | 48.25d → none |  | constraint none → start no earlier than 2006-03-13 |
| 18 | Create Detailed Architecture/Application Design | 2006-01-26 A | 2006-02-01 → 2006-02-17 A (+16d) | 17h? → 11.05h? | 0% → 100% | 5d → none |  | resources Nick → Nick; Tom |
| 19 | Review Detailed Architecture/Application Design | 2006-02-01 → 2006-02-17 A (+16d) | 2006-02-02 → 2006-02-20 A (+18d) |  | 0% → 100% | 5d → none |  |  |
| 20 | Create Integration Test Plan | 2006-02-16 → 2006-03-10 A (+22d) | 2006-02-17 → 2006-03-13 A (+24d) |  | 0% → 100% | 14d → none |  | constraint none → start no earlier than 2006-03-10 |
| 21 | Review Integration Test Plan | 2006-02-17 → 2006-03-13 A (+24d) | 2006-02-20 → 2006-03-17 A (+25d) |  | 0% → 100% | 14d → none |  | constraint none → start no earlier than 2006-03-13 |
| 22 | Detailed Component Design | 2006-02-02 → 2006-02-20 A (+18d) | 2006-02-14 → 2006-03-06 A (+20d) |  | 0% → 100% | 5d → none |  | resources Nick → Nick; Tom |
| 23 | MapPoint.NET Proof of concept on the server | 2006-02-17 A | 2006-02-17 A |  | 0% → 100% | 48.75d → none |  |  |
| 24 | Reivew Detailed Component Design | 2006-02-14 → 2006-03-06 A (+20d) | 2006-02-15 → 2006-03-08 A (+21d) |  | 0% → 100% | 5d → none |  |  |
| 25 | Create Unit Test Plan | 2006-02-20 → 2006-03-10 A (+18d) | 2006-02-23 → 2006-03-20 A (+25d) |  | 0% → 100% | 14d → none | 24, 9, 21 → 24, 9 | constraint none → start no earlier than 2006-03-10 |
| 26 | Review Unit Test Plan | 2006-02-23 → 2006-03-13 A (+18d) | 2006-02-23 → 2006-03-21 A (+26d) |  | 0% → 100% | 14d → none |  |  |
| 27 | Create and review all Test Plans | 2006-02-23 → 2006-03-20 A (+25d) | 2006-02-23 → 2006-03-20 A (+25d) |  | 0% → 100% | 43.75d → none |  |  |
| 28 | UI Paper Prototype | 2006-01-31 A | 2006-02-03 A |  | 0% → 100% | 59.75d → none |  |  |
| 29 | Sign off on UI Prototype | 2006-02-07 → 2006-02-14 A (+7d) | 2006-02-07 → 2006-02-14 A (+7d) |  | 0% → 100% | 58.75d → none |  | constraint start no earlier than 2006-02-07 → start no earlier than 2006-02-14 |
| 30 | Proof of concept with MapPoint.NET | 2006-01-09 A | 2006-01-10 A |  | 0% → 100% | 27.5d → none |  |  |
| 31 | Research/Set-up Nokia IDE | 2006-01-10 A | 2006-01-18 A |  | 0% → 100% | 27.5d → none |  |  |
| 33 | Proven interaction between the IDE and GPS Hardware |  | 2006-02-01 A |  | 20% → 100% | 17d → none |  | resources Nick; Tom → Nick; Tom; Shawn |
| 34 | JSR-179 (Subclassing and Server) implementation | 2006-02-16 → 2006-03-20 A (+32d) | 2006-03-08 → 2006-03-21 A (+13d) | 60h? → 6h? | 0% → 100% | 5d → none |  | was named Construct Components; constraint none → start no earlier than 2006-03-20; resources All → Nick |
| 52 | Unit test Response Component | 2006-03-09 → 2006-03-30 A (+21d) | 2006-03-17 → 2006-04-03 A (+17d) | 25h? → 4h? | 0% → 100% | 5d → none | 34, 26 → 26, 51 | was named Unit test each component; resources All → Nick |
| 53 | Bug Fixing (after Unit testing) | 2006-03-17 → 2006-04-24 A (+38d) | 2006-03-24 → 2006-05-04 (+41d) | 20h? → 18h? | 0% → 73% | 5d → 0d | 52 → 55 | resources All → Tom; Lora; Amanda; Shawn; Nick |
| 54 | Construct Components and conduct Unit tests | 2006-03-24 → 2006-05-04 (+41d) | 2006-03-24 → 2006-05-04 (+41d) |  |  | 5d → 16d |  |  |
| 55 | Integrate each component into system | 2006-03-24 → 2006-04-20 A (+27d) | 2006-03-28 → 2006-05-03 (+36d) |  | 0% → 90% | 5d → 0d | 54 → 34, 36, 38, 42, 40, 44, 46, 48, 50, 52 | constraint none → start no earlier than 2006-04-17 |
| 56 | Integration Testing | 2006-03-28 → 2006-05-04 (+37d) | 2006-04-03 → 2006-05-10 (+37d) |  |  | 5d → 0d |  |  |
| 57 | Bug Fixing (after integration testing) | 2006-04-03 → 2006-05-10 (+37d) | 2006-04-06 → 2006-05-15 (+39d) |  |  | 5d → 0d |  |  |
| 58 | System test | 2006-04-06 → 2006-05-15 (+39d) | 2006-04-10 → 2006-05-17 (+37d) |  |  | 5d → 0d |  |  |
| 59 | Bug Fixing (after System testing) | 2006-04-11 → 2006-05-17 (+36d) | 2006-04-13 → 2006-05-22 (+39d) |  |  | 5d → 0d |  |  |
| 60 | Acceptance test | 2006-04-13 → 2006-05-22 (+39d) | 2006-04-17 → 2006-05-24 (+37d) |  |  | 5d → 0d |  |  |
| 61 | Bug Fixing (after Acceptance testing) | 2006-04-17 → 2006-05-24 (+37d) | 2006-04-19 → 2006-05-26 (+37d) |  |  | 5d → 0d |  |  |
| 62 | Sign off on application | 2006-04-19 → 2006-05-26 (+37d) | 2006-04-19 → 2006-05-26 (+37d) |  |  | 5d → 0d |  |  |
| 63 | Put together first quarter presentation | 2006-02-17 A | 2006-02-21 A |  | 0% → 100% | 0d → none |  |  |
| 64 | Put together second quarter presentation | 2006-04-19 → 2006-05-05 A (+16d) | 2006-04-26 → 2006-05-11 (+15d) |  | 0% → 20% | 19d → 1.75d | 63, 61 → 63 | constraint start no earlier than 2006-04-10 → start no earlier than 2006-05-05 |
| 65 | Investigate SOAP and MapPoint.NET interaction | 2006-01-24 A | 2006-01-26 → 2006-02-08 A (+13d) | 10h? → 7h? | 0% → 100% | 66d → none |  |  |
| 66 | Create Users Manual | 2006-03-13 → 2006-05-01 (+49d) | 2006-03-16 → 2006-05-04 (+49d) |  |  | 29d → 13.25d |  | constraint start no earlier than 2006-03-13 → start no earlier than 2006-05-01 |
| 67 | Determine process for compiliation | 2006-01-26 A | 2006-01-26 A |  | 0% → 100% | 66.25d → none |  |  |
| 68 | Compile metrics |  | 2006-04-11 → 2006-04-19 (+8d) |  | 4% → 80% | 10.75d → 27.2d |  |  |
| 69 | Create Technical Report | 2006-04-03 → 2006-03-20 A (-14d) | 2006-04-06 → 2006-04-20 (+14d) | 15h? → 20h? | 0% → 70% | 14d → 26.2d |  | constraint start no earlier than 2006-04-02 → start no earlier than 2006-03-20 |
